# Procurement Programme 01-12-05

Schedule from MS Project, 2005-11-14 to 2007-07-30.
Haringey Council

## Calendars

- Standard: Mon-Fri 08:00-12:00, 13:00-17:00; Sat-Sun off. Exceptions (off unless hours are given): 2006-10-14 08:00-12:00, 13:00-17:00.

## Schedule

| ID | WBS | Task | Duration | Start | Finish | Predecessors | Baseline start | Baseline finish | Baseline duration | Total slack | Free slack | Constraint |
| --- | --- | --- | --- | --- | --- | --- | --- | --- | --- | --- | --- | --- |
| 1 | 1 | **General Procurement** | 447d | 2005-11-14 | 2007-07-30 |  | 2005-11-14 | 2007-07-02 | 426d | 0d |  |  |
| 2 | 1.1 | SBC to PfS/DfES | 13d | 2005-11-14 | 2005-11-30 |  | 2005-11-14 | 2005-11-30 | 13d | 398d |  | start no earlier than 2005-11-14 |
| 3 | 1.2 | Mtg SMIF to discuss Heads of Terms | 1d | 2005-12-12 | 2005-12-12 |  | 2005-12-14 | 2005-12-16 | 3d | 390d |  | start no earlier than 2005-12-12 |
| 4 | 1.3 | Draft Heads of Terms to JPMT | 10d | 2005-12-12 | 2005-12-23 |  | 2005-12-26 | 2005-12-30 | 5d | 381d |  | start no earlier than 2005-12-12 |
| 5 | 1.4 | QC Procurement Advice | 15d | 2005-12-05 | 2005-12-23 |  | 2005-12-26 | 2005-12-30 | 5d | 381d |  | start no earlier than 2005-12-05 |
| 6 | 1.5 | Soft Market Testing | 63d | 2006-02-01 | 2006-04-30 |  |  |  |  | 291d |  | finish no earlier than 2006-04-30 |
| 7 | 1.6 | Governors approvals to revenue | 35d | 2006-01-09 | 2006-02-24 |  |  |  |  | 336d |  | finish no earlier than 2006-02-24 |
| 8 | 1.7 | Draft OBC (1) to PfS | 42d | 2006-01-02 | 2006-02-28 |  | 2005-12-30 | 2005-12-30 | 1d | 334d |  | start no earlier than 2006-01-02 |
| 9 | 1.8 | Complete OBC (2) | 56d | 2006-01-03 | 2006-03-21 |  | 2006-01-02 | 2006-01-27 | 20d | 316d | 0d | finish no earlier than 2006-03-21 |
| 10 | 1.9 | OBC (1) and (2) to PfS | 3d | 2006-03-22 | 2006-03-24 | 9 | 2006-02-15 | 2006-02-17 | 3d | 316d |  | start no earlier than 2006-02-15 |
| 11 | 1.10 | Appoint LEA Officers to JPMT Board | 35d | 2006-01-09 | 2006-02-24 |  | 2006-01-16 | 2006-02-03 | 15d | 336d |  | start no earlier than 2006-01-09 |
| 12 | 1.11 | PBC Approved in Principle HofT Agreed | 41d | 2006-01-03 | 2006-02-28 |  | 2006-02-15 | 2006-02-28 | 10d | 334d |  | start no earlier than 2006-01-03 |
| 13 | 1.12 | Solicitors Prepare Agreement with SMIF | 43d | 2006-03-01 | 2006-04-28 |  | 2006-02-27 | 2006-02-28 | 2d | 291d |  | start no earlier than 2006-03-01 |
| 14 | 1.13 | SBC Approved | 1d | 2006-02-28 | 2006-02-28 |  | 2006-02-28 | 2006-02-28 | 1d | 334d |  | start no earlier than 2006-02-28 |
| 15 | 1.14 | Convene JPMT Board | 20d | 2006-03-03 | 2006-03-30 |  |  |  |  | 226d | 1d | finish no earlier than 2006-03-30 |
| 16 | 1.15 | Confirm Programme Managers(assume on OJEU) | 23d | 2006-03-01 | 2006-03-31 |  | 2006-02-06 | 2006-02-14 | 7d | 311d |  | start no earlier than 2006-03-01 |
| 17 | 1.16 | Appoint Education Advisors | 23d | 2006-03-01 | 2006-03-31 |  |  |  |  | 311d |  | start no earlier than 2006-03-01 |
| 18 | 1.17 | OJEU for Appoint of Architects/Design Team | 31d | 2006-02-24 | 2006-04-07 |  | 2006-02-27 | 2006-02-28 | 2d | 306d |  | start no earlier than 2006-02-24 |
| 19 | 1.18 | Evaluate and shortlist | 11d | 2006-04-07 | 2006-04-21 |  |  |  |  | 296d |  | start no earlier than 2006-04-07 |
| 20 | 1.19 | Design Competition | 21d | 2006-04-28 | 2006-05-26 |  |  |  |  | 271d |  | start no earlier than 2006-04-28 |
| 21 | 1.20 | Select Preferred Designer(s) | 16d | 2006-05-26 | 2006-06-16 |  |  |  |  | 256d |  | start no earlier than 2006-05-26 |
| 22 | 1.21 | Produce & Confirm Master Programme/Execution Plan | 21d | 2006-03-03 | 2006-03-31 |  | 2006-02-15 | 2006-02-17 | 3d | 311d |  | start no earlier than 2006-03-03 |
| 23 | 1.22 | OBC (1) &(2) to CEMB | 2d | 2006-03-07 | 2006-03-08 |  | 2006-02-27 | 2006-02-28 | 2d | 328d |  | finish no earlier than 2006-03-08 |
| 24 | 1.23 | OBC (1) & (2) to Exec | 1d | 2006-03-24 | 2006-03-24 |  | 2006-03-24 | 2006-03-24 | 1d | 316d |  | start no earlier than 2006-03-24 |
| 25 | 1.24 | OBC (1) & (2) approved by PfS/DfES | 26d | 2006-03-24 | 2006-04-28 |  | 2006-04-14 | 2006-04-14 | 1d | 291d |  | start no earlier than 2006-03-24 |
| 26 | 1.25 | PBC Approved by PfS/DfES | 26d | 2006-03-24 | 2006-04-28 |  | 2006-04-14 | 2006-04-14 | 1d | 291d |  | start no earlier than 2006-03-24 |
| 27 | 1.26 | Commence Outline Designs | 91d | 2006-06-23 | 2006-10-26 |  | 2006-04-24 | 2006-04-28 | 5d | 197d |  | start no earlier than 2006-06-23 |
| 28 | 1.27 | Issue OJEU Notices for 1st Scheme Contractors | 1d | 2006-05-01 | 2006-05-01 |  | 2006-05-01 | 2006-05-01 | 1d | 290d |  | start no earlier than 2006-05-01 |
| 29 | 1.28 | Legals for Build Contracts | 86d | 2006-04-03 | 2006-07-31 | 15 | 2006-04-03 | 2006-07-31 | 86d | 225d |  | start no earlier than 2006-04-03 |
| 30 | 1.29 | Submit Planning Applications | 6d | 2006-08-14 | 2006-08-21 |  | 2006-06-01 | 2006-06-30 | 22d | 246d |  | start no earlier than 2006-08-14 |
| 31 | 1.30 | Deadline for EOI to OJEU | 1d | 2006-06-14 | 2006-06-14 |  | 2006-06-14 | 2006-06-14 | 1d | 258d |  | start no earlier than 2006-06-14 |
| 32 | 1.31 | Evaluate OJEU Responses | 23d | 2006-06-14 | 2006-07-14 |  | 2006-06-14 | 2006-07-14 | 23d | 236d |  | start no earlier than 2006-06-14 |
| 33 | 1.32 | shortlist contractors | 11d | 2006-07-14 | 2006-07-28 |  |  |  |  | 226d |  | start no earlier than 2006-07-14 |
| 34 | 1.33 | Prepare Tender Docs | 40d | 2006-09-07 | 2006-10-31 |  | 2006-06-01 | 2006-07-31 | 43d | 193d | 0d | start no earlier than 2006-09-07 |
| 35 | 1.34 | Issue Tenders | 1d | 2006-11-01 | 2006-11-01 | 34 | 2006-08-01 | 2006-08-01 | 1d | 193d |  |  |
| 36 | 1.35 | Tender Period | 67d | 2006-11-02 | 2007-02-02 |  |  |  |  | 126d |  | start no earlier than 2006-11-02 |
| 37 | 1.36 | Obtain Planning Approvals | 21d | 2006-10-14 | 2006-11-10 |  | 2006-09-14 | 2006-09-14 | 1d | 186d |  | start no earlier than 2006-10-14 |
| 38 | 1.37 | Receive Bids | 1d | 2007-02-02 | 2007-02-02 |  | 2006-11-01 | 2006-11-01 | 1d | 126d |  | start no earlier than 2007-02-02 |
| 39 | 1.38 | Evaluate/Clarification | 37d | 2007-02-08 | 2007-03-30 |  | 2006-11-06 | 2006-12-29 | 40d | 86d |  | start no earlier than 2007-02-08 |
| 40 | 1.39 | Appoint Preferred Bidder(s) | 6d | 2007-04-06 | 2007-04-13 |  | 2007-01-04 | 2007-01-31 | 20d | 76d |  | start no earlier than 2007-04-06 |
| 41 | 1.40 | Contract Close | 11d | 2007-04-13 | 2007-04-27 |  | 2007-02-01 | 2007-02-01 | 1d | 66d |  | start no earlier than 2007-04-13 |
| 42 | 1.41 | Complete Detailed Designs | 66d | 2007-04-27 | 2007-07-27 |  | 2007-06-29 | 2007-06-29 | 1d | 0d |  | start no earlier than 2007-04-27 |
| 43 | 1.42 | Commence Construction | 1d | 2007-07-30 | 2007-07-30 | 42 | 2007-07-02 | 2007-07-02 | 1d | 0d |  |  |

| ID | WBS | Task | Duration | Start | Finish | Predecessors | Baseline start | Baseline finish | Baseline duration | Total slack | Free slack | Constraint |
| --- | --- | --- | --- | --- | --- | --- | --- | --- | --- | --- | --- | --- |
| 44 | 2 | **ICT MSP** | 272d | 2005-12-01 | 2006-12-14 |  | 2005-12-12 | 2006-11-15 | 243d | 162d |  |  |
| 46 | 2.1 | Appoint ICT Consultants | 1d | 2006-02-28 | 2006-02-28 |  | 2005-12-12 | 2005-12-12 | 1d | 370d |  | start no earlier than 2006-02-28 |
| 47 | 2.2 | Prepare OJEU | 20d | 2006-04-03 | 2006-04-28 |  |  |  |  | 327d |  | start no earlier than 2006-04-03 |
| 48 | 2.3 | Issue OJEU for ICT MSP | 3d | 2006-05-01 | 2006-05-03 |  | 2006-02-01 | 2006-02-02 | 2d | 324d |  | start no earlier than 2006-05-01 |
| 49 | 2.4 | Receive EOI | 35d | 2006-05-01 | 2006-06-16 |  | 2006-03-15 | 2006-03-15 | 1d | 292d |  | start no earlier than 2006-05-01 |
| 50 | 2.5 | Evaluate Responses | 30d | 2006-06-16 | 2006-07-27 |  | 2006-04-14 | 2006-04-14 | 1d | 263d |  | start no earlier than 2006-06-16 |
| 51 | 2.6 | Prepare Tender Docs | 30d | 2006-06-16 | 2006-07-27 |  | 2006-05-01 | 2006-06-23 | 40d | 263d |  | finish no earlier than 2006-07-27 |
| 52 | 2.7 | Issue Tender Docs | 1d | 2006-07-31 | 2006-07-31 |  | 2006-07-03 | 2006-07-03 | 1d | 261d |  | start no earlier than 2006-07-31 |
| 53 | 2.8 | Tender Period | 55d | 2006-07-31 | 2006-10-13 |  |  |  |  | 207d |  | start no earlier than 2006-07-31 |
| 54 | 2.9 | Receive Bids | 2d | 2006-10-13 | 2006-10-14 |  | 2006-09-14 | 2006-09-15 | 2d | 206d |  | start no earlier than 2006-10-13 |
| 55 | 2.10 | Evaluate/Clarify Bids | 22d | 2006-10-14 | 2006-11-13 |  | 2006-09-14 | 2006-10-13 | 22d | 185d |  | start no earlier than 2006-10-14 |
| 56 | 2.11 | Appoint Preferred Bidder | 1d | 2006-11-13 | 2006-11-13 |  | 2006-10-13 | 2006-10-13 | 1d | 185d |  | start no earlier than 2006-11-13 |
| 57 | 2.12 | Financial Close | 24d | 2006-11-13 | 2006-12-14 |  | 2006-11-15 | 2006-11-15 | 1d | 162d |  | start no earlier than 2006-11-13 |
| 58 | 3 | **Life Cycle/FM Providers** | 144d | 2006-05-01 | 2006-11-15 |  | 2006-05-01 | 2006-11-15 | 143d | 183d |  |  |
| 59 | 3.1 | Issue OJEU Notice for Life Cycle FM | 1d | 2006-05-01 | 2006-05-01 |  | 2006-05-01 | 2006-05-01 | 1d | 290d |  | start no earlier than 2006-05-01 |
| 60 | 3.2 | Legals with SMIF | 66d | 2006-05-01 | 2006-07-31 |  | 2006-05-01 | 2006-07-31 | 66d | 225d |  | start no earlier than 2006-05-01 |
| 61 | 3.3 | Deadline EOI | 1d | 2006-06-14 | 2006-06-14 |  | 2006-06-14 | 2006-06-14 | 1d | 258d |  | start no earlier than 2006-06-14 |
| 62 | 3.4 | Evaluate Responses | 23d | 2006-06-14 | 2006-07-14 |  | 2006-06-14 | 2006-07-14 | 23d | 236d |  | start no earlier than 2006-06-14 |
| 63 | 3.5 | Prepare Tender Docs | 43d | 2006-06-01 | 2006-07-31 |  | 2006-06-01 | 2006-07-31 | 43d | 223d | 0d | start no earlier than 2006-06-01 |
| 64 | 3.6 | Issue Tenders | 2d | 2006-08-01 | 2006-08-02 | 63 | 2006-08-01 | 2006-08-02 | 2d | 223d |  |  |
| 65 | 3.7 | Tender Period | 54d | 2006-08-01 | 2006-10-13 |  |  |  |  | 171d |  | start no earlier than 2006-08-01 |
| 66 | 3.8 | Receive Bids | 1d | 2006-10-13 | 2006-10-13 |  | 2006-10-13 | 2006-10-13 | 1d | 171d |  | start no earlier than 2006-10-13 |
| 67 | 3.9 | Evaluate Bids | 24d | 2006-10-13 | 2006-11-14 |  | 2006-10-13 | 2006-11-15 | 24d | 184d |  | start no earlier than 2006-10-13 |
| 68 | 3.10 | Appoint Preferred Bidders | 1d | 2006-11-15 | 2006-11-15 |  | 2006-11-01 | 2006-11-02 | 2d | 148d |  | start no earlier than 2006-11-15 |
